# Home Construction

Schedule from Primavera P6, 2014-10-15 to 2014-11-20, data date 2014-10-17.

## Calendars

- Calendar 1: Mon off; Tue-Sat 09:00-14:00, 15:00-19:00; Sun off.

## Schedule

| ID | WBS | Activity | Type | Duration | Start | Finish | Predecessors | Planned start | Planned finish | Total float | Free float |
| --- | --- | --- | --- | --- | --- | --- | --- | --- | --- | --- | --- |
| A1000 |  | Project Start | milestone | 0d | 2014-10-17 | 2014-10-17 |  | 2014-10-14 | 2014-10-14 |  |  |
| A1010 |  | Project Management | level of effort | 32d | 2014-10-17 | 2014-11-19 | A1000 SS | 2014-10-14 | 2014-11-21 | 1d | 0d |
| A1020 |  | Project Complete | milestone | 0d | 2014-11-19 | 2014-11-19 | A1010 FF, A1150, A1170 FF, A1240 FF, A1210 FF |  |  | 1d |  |
|  | 1 | **Grading** |  |  | 2014-10-15 | 2014-10-22 |  |  |  |  |  |
| A1040 |  | Grade Site |  | 5d | 2014-10-15 | 2014-10-22 | A1030 |  |  |  |  |
| A1030 |  | Survey and mark out Site |  | 2d | 2014-10-17 | 2014-10-17 | A1000 SS | 2014-10-14 | 2014-10-15 |  |  |
|  | 2 | **Foundation** |  |  | 2014-10-18 | 2014-10-24 |  |  |  |  |  |
| A1050 |  | Laying of Foundation |  | 2d | 2014-10-18 | 2014-10-22 | A1040 |  |  |  |  |
| A1060 |  | Slab Plumbing |  | 1d | 2014-10-22 | 2014-10-23 | A1050 |  |  | 0d |  |
| A1070 |  | Pour and float slab concrete |  | 1d | 2014-10-23 | 2014-10-24 | A1060 |  |  | 0d |  |
|  | 3 | **Structure** |  |  | 2014-10-17 | 2014-11-20 |  |  |  |  |  |
|  | 1 | **Framing** |  |  | 2014-11-01 | 2014-11-14 |  |  |  |  |  |
| A1080 |  | Exterior Walls |  | 6d | 2014-11-01 | 2014-11-08 | A1070 FS+7d |  |  | 0d |  |
| A1090 |  | Interior Walls |  | 4d | 2014-11-08 | 2014-11-14 | A1080 |  |  | 5d |  |
| A1100 |  | Exterior Cladding |  | 2d | 2014-11-08 | 2014-11-12 | A1080 |  |  | 1d | 0d |
|  | 2 | **Roof** |  |  | 2014-11-08 | 2014-11-15 |  |  |  |  |  |
| A1110 |  | Truss Placing |  | 2d | 2014-11-08 | 2014-11-12 | A1080 |  |  | 2d | 0d |
| A1120 |  | Roof Sheeting |  | 1d | 2014-11-12 | 2014-11-13 | A1110 |  |  | 2d | 0d |
| A1130 |  | Place Paper and Shingles |  | 2d | 2014-11-13 | 2014-11-15 | A1120 |  |  | 2d | 0d |
|  | 3 | **Interior** |  |  | 2014-10-17 | 2014-11-20 |  |  |  |  |  |
|  | 1 | **Mechanical** |  |  | 2014-11-15 | 2014-11-19 |  |  |  |  |  |
| A1140 |  | HVAC Ducting |  | 2d | 2014-11-15 | 2014-11-19 | A1130 |  |  | 2d | 0d |
| A1150 |  | Install HVAC Unit |  | 1d | 2014-11-15 | 2014-11-18 | A1140 SS |  |  | 3d | 2d |
|  | 2 | **Electrical** |  |  | 2014-11-08 | 2014-11-18 |  |  |  |  |  |
| A1160 |  | Breaker Box and Rough Wiring |  | 3d | 2014-11-08 | 2014-11-13 | A1080 |  |  | 3d | 0d |
| A1170 |  | Finish Wiring |  | 3d | 2014-11-13 | 2014-11-18 | A1160 |  |  | 3d | 2d |

| ID | WBS | Activity | Duration | Start | Finish | Predecessors | Total float | Free float |
| --- | --- | --- | --- | --- | --- | --- | --- | --- |
|  | 3 | **Plumbing** |  | 2014-11-08 | 2014-11-14 |  |  |  |
| A1180 |  | Install Rough Plumbing Lines | 4d | 2014-11-08 | 2014-11-14 | A1080 | 0d |  |
|  | 4 | **Decor** |  | 2014-10-17 | 2014-11-20 |  |  |  |
| A1210 |  | Kitchen Cabinets | 5d | 2014-10-17 | 2014-10-23 |  | 23d | 22d |
| A1190 |  | Placing Doors | 2d | 2014-11-14 | 2014-11-18 | A1180 | 0d |  |
| A1200 |  | Doors Casing and Baseboards | 3d | 2014-11-18 | 2014-11-20 | A1190 | 0d |  |
|  | 4 | **Exterior** |  | 2014-11-12 | 2014-11-19 |  |  |  |
| A1220 |  | Place Windows | 2d | 2014-11-12 | 2014-11-14 | A1100 | 1d | 0d |
| A1230 |  | Window Sidings | 3d | 2014-11-14 | 2014-11-19 | A1220 | 1d | 0d |
|  | 5 | **Landscaping** |  | 2014-11-19 | 2014-11-19 |  |  |  |
| A1240 |  | Tree Plantings | 1d | 2014-11-19 | 2014-11-19 | A1230 | 1d | 0d |
